# AL-03 - met heiwerk

Schedule from MS Project, 2003-01-12 to 2003-01-31, status date 2003-01-08.
BAM Nelissen Van Egteren

## Calendars

- ALLEEN WERKDAGEN: Mon-Fri 08:30-12:30, 13:00-17:00; Sat-Sun off. Exceptions (off unless hours are given): 2003-01-11 to 2003-01-12 08:30-12:30, 13:00-17:00, 2003-01-18 to 2003-01-19 08:30-12:30, 13:00-17:00, 2003-01-25 to 2003-01-26 08:30-12:30, 13:00-17:00.

## Schedule

| ID | WBS | Task | Type | Duration | Start | Finish | Predecessors | Total slack |
| --- | --- | --- | --- | --- | --- | --- | --- | --- |
| 1 | 1 | **AANLOOPFASE** |  | 20d | 2003-01-12 | 2003-01-31 |  | 0d |
| 2 | 1.1 | keten/loodsen/afrastering |  | 5d | 2003-01-12 | 2003-01-16 |  | 0d |
| 3 | 1.2 | bouwinstallatie aanleggen |  | 5d | 2003-01-13 | 2003-01-17 | 2SS+1d | 0d |
| 4 | 1.3 | bouwwegen aanleggen |  | 4d | 2003-01-14 | 2003-01-17 | 3SS+1d | 0d |
| 5 | 1.4 | uitzetten+bouwplanken |  | 2d | 2003-01-16 | 2003-01-17 | 4SS+2d | 0d |
| 6 | 1.5 | bouwput ontgraven |  | 3d | 2003-01-18 | 2003-01-20 | 5SS+2d | 0d |
| 7 | 1.6 | heipiketten uitzetten |  | 1d | 2003-01-21 | 2003-01-21 | 6SS+3d | 0d |
| 8 | 1.7 | betonpalen heien |  | 5d | 2003-01-22 | 2003-01-26 | 7SS+1d | 0d |
| 9 | 1.8 | paalkoppen snellen |  | 2d | 2003-01-27 | 2003-01-28 | 8SS+5d | 0d |
| 10 | 1.9 | paalkoppen afvoeren |  | 2d | 2003-01-29 | 2003-01-30 | 9SS+2d | 0d |
| 11 | 1.10 | maatvoeren funderingsbalken |  | 1d | 2003-01-31 | 2003-01-31 | 10SS+2d | 0d |
| 12 | 1.11 | start onderbouw | milestone | 0d | 2003-01-31 | 2003-01-31 | 11SS+1d | 0d |
